# projecto-DSpace

Schedule from MS Project, 2016-02-09 to 2016-06-24.

## Calendars

- Standard: Mon-Fri 08:00-12:00, 13:00-17:00; Sat-Sun off.

## Schedule

| ID | WBS | Task | Duration | Start | Finish | Predecessors | Total slack | Free slack | Constraint |
| --- | --- | --- | --- | --- | --- | --- | --- | --- | --- |
| 1 | 1 | **Consolidación de repositorio institucional** | 99d? | 2016-02-09 | 2016-06-24 |  | 0d |  |  |
| 2 | 1.1 | **Análisis** | 39d? | 2016-02-09 | 2016-04-01 |  | 60d |  |  |
| 3 | 1.1.1 | **Alcances del repositorio** | 4d? | 2016-02-09 | 2016-02-12 |  | 95d |  |  |
| 4 | 1.1.1.1 | Análisis de situación actual | 1d? | 2016-02-09 | 2016-02-09 |  | 98d |  |  |
| 5 | 1.1.1.2 | Dimensionar cantidad de usuarios , tipos de archivos, volumen de información a soportar por el repositorio | 3d? | 2016-02-10 | 2016-02-12 |  | 95d |  | finish no earlier than 2016-02-12 |
| 6 | 1.1.2 | **Infraestructura tecnológica requerida** | 17d? | 2016-02-22 | 2016-03-15 |  | 73d |  |  |
| 7 | 1.1.2.1 | Decidir y documentar el software y el gestor de BD para la implementación del repositorio | 3d? | 2016-02-22 | 2016-02-24 |  | 73d | 0d | finish no earlier than 2016-02-24 |
| 8 | 1.1.2.2 | Adquirir el hardware que soportará el software y almacenamiento del repositorio | 5d? | 2016-02-25 | 2016-03-02 | 7 | 73d | 0d | start no earlier than 2016-02-25 |
| 9 | 1.1.2.3 | Contar con los recursos de red y seguridad para la implementación del repositorio | 5d? | 2016-03-03 | 2016-03-09 | 8 | 73d | 0d | finish no earlier than 2016-03-09 |
| 10 | 1.1.2.4 | Investigar el costo del licenciamiento del software que se utilizará en el repositorio | 4d? | 2016-03-10 | 2016-03-15 | 9 | 73d |  | start no earlier than 2016-03-10 |
| 11 | 1.1.3 | **Analizar la base de datos del repositorio** | 6d? | 2016-03-16 | 2016-03-23 |  | 67d |  |  |
| 12 | 1.1.3.1 | Documentar el diagrama ER de la BD del repositorio | 3d? | 2016-03-16 | 2016-03-18 |  | 67d | 0d | finish no earlier than 2016-03-18 |
| 13 | 1.1.3.2 | Documentar la configuración de BD del repositorio | 3d? | 2016-03-21 | 2016-03-23 | 12 | 67d |  |  |
| 14 | 1.1.4 | **Analizar el tipo de autentificación para accesar al repositorio** | 4d? | 2016-03-23 | 2016-03-28 |  | 64d |  |  |
| 15 | 1.1.4.1 | Determinar si es mejor el acceso local o mediante un directorio activo de usuarios | 4d? | 2016-03-23 | 2016-03-28 |  | 64d |  | finish no earlier than 2016-03-28 |
| 16 | 1.1.5 | **Analizar la instalación y configuración del software del repositorio** | 26d? | 2016-02-26 | 2016-04-01 |  | 60d |  |  |
| 17 | 1.1.5.1 | Investigar la configuración de los archivos del software del repositorio | 6d? | 2016-02-26 | 2016-03-04 |  | 68d | 0d | finish no earlier than 2016-03-04 |
| 18 | 1.1.5.2 | Investigar la configuración de los patch del sistema | 3d? | 2016-03-07 | 2016-03-09 | 17 | 68d | 0d | start no earlier than 2016-03-07 |
| 19 | 1.1.5.3 | Investigar los comandos y procedimientos de instalación | 3d? | 2016-03-10 | 2016-03-14 | 18 | 68d | 0d | finish no earlier than 2016-03-14 |
| 20 | 1.1.5.4 | Analizar el diseño de interfaces del repositorio | 6d? | 2016-03-15 | 2016-03-22 | 19 | 68d |  | start no earlier than 2016-03-15 |
| 21 | 1.1.5.5 | Documentar el manual de instalación | 5d? | 2016-03-28 | 2016-04-01 |  | 60d |  | finish no earlier than 2016-04-01 |
| 23 | 1.2 | **Implementación-Pruebas** | 42d? | 2016-04-04 | 2016-05-31 |  | 18d |  |  |
| 24 | 1.2.1 | **Instalar e implementar el repositorio en un laboratorio de pruebas** | 5d? | 2016-04-04 | 2016-04-08 |  | 55d |  |  |
| 25 | 1.2.1.1 | Instalar el software complementario para el funcionamiento del reporsitorio | 1d? | 2016-04-04 | 2016-04-04 |  | 56d | 0d | finish no earlier than 2016-04-04 |
| 26 | 1.2.1.2 | Configurar los patch del sistema y archivos de configuración identificados en la etapa de análisis | 1d? | 2016-04-05 | 2016-04-05 | 25 | 56d | 1d | finish no earlier than 2016-04-05 |
| 27 | 1.2.1.3 | Instalar el gestor de la base de datos, configurar la BD e instalar el software del repositorio | 2d? | 2016-04-07 | 2016-04-08 | 26 | 55d |  | finish no earlier than 2016-04-08 |

| ID | WBS | Task | Duration | Start | Finish | Predecessors | Total slack | Free slack | Constraint |
| --- | --- | --- | --- | --- | --- | --- | --- | --- | --- |
| 28 | 1.2.2 | **Personalizar las interfaces del software del repositorio** | 13d? | 2016-04-11 | 2016-04-27 |  | 42d |  |  |
| 29 | 1.2.2.1 | Agregar el proyecto de codificación del repositorio a un ambiente de desarrollo Java | 3d? | 2016-04-11 | 2016-04-13 |  | 42d | 0d | finish no earlier than 2016-04-13 |
| 30 | 1.2.2.2 | Agregar los colores y el logo de nuestra institución en las interfaces del software del repositorio. | 2d? | 2016-04-14 | 2016-04-15 | 29 | 42d | 0d | start no earlier than 2016-04-14 |
| 31 | 1.2.2.3 | Modificar textos de información, error y ayuda. | 2d? | 2016-04-18 | 2016-04-19 | 30 | 42d | 0d | finish no earlier than 2016-04-19 |
| 32 | 1.2.2.4 | Modificar el diseño de la pagina principal o en su caso también de las interfaces. | 6d? | 2016-04-20 | 2016-04-27 | 31 | 42d |  |  |
| 33 | 1.2.3 | **Realizar pruebas y correción de errores face 1** | 5d? | 2016-04-28 | 2016-05-04 |  | 37d |  |  |
| 34 | 1.2.3.1 | Realizar pruebas de acceso y correción de errores de las dos etapas anteriores | 2d? | 2016-04-28 | 2016-04-29 |  | 37d | 0d | finish no earlier than 2016-04-29 |
| 35 | 1.2.3.2 | Actualizar el manual de instalación | 3d? | 2016-05-02 | 2016-05-04 | 34 | 37d |  | start no earlier than 2016-05-02 |
| 36 | 1.2.4 | **Recibir entrenamiento de la administración del repositorio** | 8d? | 2016-05-04 | 2016-05-13 |  | 30d |  |  |
| 37 | 1.2.4.1 | Introducción y administración básica del repositorio | 2d? | 2016-05-04 | 2016-05-05 |  | 32d | 2d | finish no earlier than 2016-05-05 |
| 38 | 1.2.4.2 | Administración avanzada I | 1d? | 2016-05-10 | 2016-05-10 | 37 | 30d | 0d | finish no earlier than 2016-05-10 |
| 39 | 1.2.4.3 | Administración avanzada II | 3d? | 2016-05-11 | 2016-05-13 | 38 | 30d |  |  |
| 40 | 1.2.5 | **Realizar la administración del repositorio** | 3d? | 2016-05-16 | 2016-05-18 |  | 27d |  |  |
| 41 | 1.2.5.1 | Personalizar la administración del repositorio según las necesidades de la institución | 3d? | 2016-05-16 | 2016-05-18 |  | 27d |  | finish no earlier than 2016-05-18 |
| 42 | 1.2.6 | **Realizar pruebas y correción de errores face 2** | 2d? | 2016-05-19 | 2016-05-20 |  | 25d |  |  |
| 43 | 1.2.6.1 | Realizar pruebas y corección de errores de acceso y administración del repositorio. | 2d? | 2016-05-19 | 2016-05-20 |  | 25d |  | finish no earlier than 2016-05-20 |
| 44 | 1.2.7 | **Tener manuales de instalación y administración** | 7d? | 2016-05-23 | 2016-05-31 |  | 18d |  |  |
| 45 | 1.2.7.1 | Elaborar un manual detallado de instalación | 3d? | 2016-05-23 | 2016-05-25 |  | 21d | 3d | finish no earlier than 2016-05-25 |
| 46 | 1.2.7.2 | Elaborar un manual detallado de administración | 1d? | 2016-05-31 | 2016-05-31 | 45 | 18d |  | finish no earlier than 2016-05-31 |
| 48 | 1.3 | **Implementación-Producción** | 18d? | 2016-06-01 | 2016-06-24 |  | 0d |  |  |
| 49 | 1.3.1 | **Poner al servidor del repositorio en modo de producción** | 10d? | 2016-06-01 | 2016-06-14 |  | 8d |  |  |
| 50 | 1.3.1.1 | Montar el servidor del repositorio en el site y realizar las configuraciones pertinentes para su despliegue | 5d? | 2016-06-01 | 2016-06-07 |  | 12d | 4d | finish no earlier than 2016-06-07 |
| 51 | 1.3.1.2 | Verificar el completo despliegue y acceso al repositorio | 1d? | 2016-06-14 | 2016-06-14 | 50 | 8d |  | finish no earlier than 2016-06-14 |
| 52 | 1.3.2 | **Administrar el repositorio de forma activa** | 8d? | 2016-06-15 | 2016-06-24 |  | 0d |  |  |
| 53 | 1.3.2.1 | Administrar de manera full el reposositorio (usuario y administrador) | 8d? | 2016-06-15 | 2016-06-24 |  | 0d |  | start no earlier than 2016-06-15 |
